# wgo revamp

Schedule from Planner, 2006-08-18 to 2006-10-17.
Phase: 2.16

## Calendars

- Defecte: Mon-Sun 00:00-23:59.

## Resources

| Resource | Group |
| --- | --- |
| Michael Maclean | planning |
| Simon Rozet | planning |
| Translator X | i18n |
| Máirín Duffy | artwork |
| Lee Tambiah | planning |
| Quim Gil | planning |
| Joachim Noreiko | planning |
| Gergerly Nagy | planning |
| Sigurd Gartmann | planning |

## Schedule

| ID | WBS | Task | Type | Duration | Start | Finish | Predecessors | Complete | Constraint | Resources | Work |
| --- | --- | --- | --- | --- | --- | --- | --- | --- | --- | --- | --- |
| 1 | 1 | 2.16 release | milestone | 0d | 2006-09-06 | 2006-09-06 |  |  | must start on 2006-09-06 |  |  |
| 2 | 2 | 2.16.1 release | milestone | 0d | 2006-10-04 | 2006-10-04 |  |  | must start on 2006-10-04 |  |  |
| 3 | 3 | **Policies** |  |  | 2006-08-18 | 2006-08-22 |  |  |  | Sigurd Gartmann | 119.91h |
| 4 | 3.1 | Policies Draft |  |  | 2006-08-18 | 2006-08-20 |  | 100% |  | Sigurd Gartmann | 71.95h |
| 5 | 3.2 | Policies Revision |  |  | 2006-08-20 | 2006-08-22 | 4 | 100% |  | Sigurd Gartmann | 47.97h |
| 6 | 4 | **Core planning** |  |  | 2006-08-18 | 2006-09-17 |  |  |  | Quim Gil | 743.47h |
| 7 | 4.1 | **Scope** |  |  | 2006-08-18 | 2006-08-24 |  |  |  | Joachim Noreiko | 167.87h |
| 8 | 4.1.1 | Scope Draft |  |  | 2006-08-18 | 2006-08-20 |  | 100% |  | Joachim Noreiko | 71.95h |
| 9 | 4.1.2 | Scope Revision |  |  | 2006-08-20 | 2006-08-22 | 8 | 100% |  | Joachim Noreiko | 47.97h |
| 10 | 4.1.3 | *go Partitioning draft |  |  | 2006-08-20 | 2006-08-22 | 8 | 100% |  | Quim Gil | 47.97h |
| 11 | 4.1.4 | *go Partitioning revision |  |  | 2006-08-22 | 2006-08-24 | 10 | 100% |  | Quim Gil | 47.97h |
| 12 | 4.2 | **Use cases** |  |  | 2006-08-18 | 2006-08-23 |  |  |  | Quim Gil | 143.89h |
| 13 | 4.2.1 | Use Draft |  |  | 2006-08-18 | 2006-08-21 |  | 100% |  | Quim Gil | 95.93h |
| 14 | 4.2.2 | Use Revision |  |  | 2006-08-21 | 2006-08-23 | 13 | 100% |  | Quim Gil | 47.97h |
| 15 | 4.3 | **Site structure** |  |  | 2006-08-21 | 2006-09-15 | 8, 13 | 75% |  | Joachim Noreiko | 599.58h |
| 16 | 4.3.1 | Site draft |  |  | 2006-08-21 | 2006-08-25 |  | 100% |  | Joachim Noreiko | 95.93h |
| 17 | 4.3.2 | Site Revision |  |  | 2006-09-09 | 2006-09-15 | 16 | 75% | must start on 2006-09-09 | Joachim Noreiko | 167.88h |
| 18 | 4.4 | **Navigation** |  |  | 2006-09-09 | 2006-09-17 | 16 |  |  | Quim Gil | 215.84h |
| 19 | 4.4.1 | Nav. Draft |  |  | 2006-09-09 | 2006-09-11 |  | 100% | must start on 2006-09-09 | Quim Gil | 71.95h |
| 20 | 4.4.2 | Nav. Revision |  |  | 2006-09-15 | 2006-09-17 | 15, 19 |  |  | Quim Gil | 47.97h |
| 21 | 5 | **Layout planning** |  |  | 2006-08-18 | 2006-09-24 |  |  |  | Lee Tambiah | 911.36h |
| 22 | 5.1 | **Page components** |  |  | 2006-08-18 | 2006-09-18 |  |  |  | Lee Tambiah | 767.46h |
| 23 | 5.1.1 | Page components draft |  |  | 2006-08-18 | 2006-08-22 |  | 100% |  | Lee Tambiah | 119.92h |
| 24 | 5.1.2 | Page components revision |  |  | 2006-08-23 | 2006-08-26 | 14 | 100% |  | Lee Tambiah | 71.95h |
| 25 | 5.1.3 | Home components draft |  |  | 2006-08-20 | 2006-08-22 | 23SS+48h | 100% |  | Lee Tambiah | 71.95h |
| 26 | 5.1.4 | Home components revision |  |  | 2006-09-15 | 2006-09-18 | 17, 25 | 100% |  | Lee Tambiah | 71.95h |

| ID | WBS | Task | Start | Finish | Predecessors | Complete | Constraint | Resources | Work |
| --- | --- | --- | --- | --- | --- | --- | --- | --- | --- |
| 27 | 5.2 | **Page structure** | 2006-08-22 | 2006-09-24 |  |  |  | Lee Tambiah | 791.45h |
| 28 | 5.2.1 | Pagestr. draft | 2006-09-08 | 2006-09-10 | 25 | 100% | must start on 2006-09-08 | Lee Tambiah | 71.95h |
| 29 | 5.2.2 | Pagestr. revision | 2006-09-21 | 2006-09-24 | 31, 28, 24 |  |  | Lee Tambiah | 71.95h |
| 30 | 5.2.3 | Homestr. draft | 2006-08-22 | 2006-08-25 | 25 | 100% |  | Lee Tambiah | 71.95h |
| 31 | 5.2.4 | Homestr. revision | 2006-09-18 | 2006-09-21 | 30, 26 | 75% |  | Lee Tambiah | 71.95h |
| 32 | 6 | **Look&Feel** | 2006-09-06 | 2006-09-27 | 1SS |  |  | Máirín Duffy | 527.62h |
| 33 | 6.1 | L&F draft | 2006-09-06 | 2006-09-20 |  | 25% |  | Máirín Duffy | 359.75h |
| 34 | 6.2 | L&F tuning | 2006-09-20 | 2006-09-27 | 33 |  |  | Máirín Duffy | 167.88h |
| 35 | 7 | **CMS selection** | 2006-09-18 | 2006-10-17 |  |  |  | Gergerly Nagy | 719.49h |
| 36 | 7.1 | 1st round draft | 2006-09-18 | 2006-09-27 |  | 10% | must start on 2006-09-18 | Gergerly Nagy | 239.83h |
| 37 | 7.2 | 1st round revision | 2006-09-27 | 2006-10-02 | 36 |  |  | Gergerly Nagy | 119.92h |
| 38 | 7.3 | final round draft | 2006-10-02 | 2006-10-12 | 33, 37 |  |  | Gergerly Nagy | 239.83h |
| 39 | 7.4 | final round revision | 2006-10-12 | 2006-10-17 | 38 |  |  | Gergerly Nagy | 119.92h |
| 40 | 7.5 | Develop test themes | 2006-09-27 | 2006-10-07 | 36, 31, 29, 33 |  |  | Lee Tambiah | 239.83h |
| 41 | 8 | Relation with gnomefiles.org | 2006-08-18 | 2006-08-18 |  | 100% |  | Quim Gil | 23.98h |
